# Cork tender and delivery

Schedule from MS Project, 2026-06-15 to 2026-09-26.

## Calendars

- Standard: Mon-Fri 08:00-12:00, 13:00-17:00; Sat-Sun off.

## Schedule

| ID | Task | Type | Duration | Start | Finish | Predecessors | Total slack | Constraint |
| --- | --- | --- | --- | --- | --- | --- | --- | --- |
| 1 | E-tender release | milestone | 0d | 2026-06-15 | 2026-06-15 |  | 0d | start no earlier than 2026-06-15 |
| 2 | Tender Period (30 Days) |  | 4w | 2026-06-15 | 2026-07-10 | 1 | 0d | start no earlier than 2026-06-05 |
| 3 | Tender Evaluation |  | 2d | 2026-07-13 | 2026-07-14 | 2 | 0d |  |
| 4 | Contractor Negotiations |  | 2w | 2026-07-14 | 2026-07-27 | 3FS-1d | 0d |  |
| 5 | Contractor Award | milestone | 0d | 2026-07-27 | 2026-07-27 | 4 | 0d |  |
| 6 | Standstill Period |  | 2w | 2026-07-28 | 2026-08-10 | 5 | 0d |  |
| 7 | Phase 1 start on site | milestone | 0d | 2026-08-10 | 2026-08-10 | 6 | 0d |  |
| 8 | Phase 1 Construction |  | 5w | 2026-08-10 | 2026-09-11 | 7FS-1d | 0d |  |
| 9 | Buffer |  | 2w | 2026-09-14 | 2026-09-25 | 8 | 0d |  |
| 10 | Phase 1 Completion | milestone | 0d | 2026-09-25 | 2026-09-25 | 8, 9 | 0d |  |
| 11 | First Round of the Laurels | milestone, manual | 0d | 2026-09-26 | 2026-09-26 | 10 |  |  |
